# House Build - House A

Schedule from MS Project, 2013-05-30 to 2014-01-22.
Schedule to build House A

## Calendars

- Standard: Mon-Fri 08:00-12:00, 13:00-17:00; Sat-Sun off.

## Resources

| Resource | Group |
| --- | --- |
| Laborer 1 | Laborer |
| Laborer 2 | Laborer |
| Ruth Tyler | Tiler |
| Master Builder |  |
| Electrician 1 | Electrician |
| Plumber 1 | Plumber |
| Carpenter 1 | Carpenter |
| Gus Pipe | Plumber |
| Lou Menns | Electrician |
| Hazel Wood | Carpenter |
| Inspector |  |
| Concrete |  |
| Bricks |  |
| Timber |  |
| Fuel |  |
| Pump |  |
| Digger |  |
| Contract Cleaner |  |

## Schedule

| ID | WBS | Task | Duration | Start | Finish | Predecessors | Total slack | Free slack |
| --- | --- | --- | --- | --- | --- | --- | --- | --- |
| 1 | 1 | **Site** | 6d | 2013-05-30 | 2013-06-06 |  | 0d |  |
| 2 | 1.1 | Clear site | 4d | 2013-05-30 | 2013-06-04 |  | 0d |  |
| 3 | 1.2 | Set out | 2d | 2013-06-05 | 2013-06-06 | 2 | 0d |  |
| 4 | 2 | **Base** | 24d | 2013-06-07 | 2013-07-10 | 1 | 0d |  |
| 5 | 2.1 | Trenches | 3d | 2013-06-07 | 2013-06-11 |  | 0d |  |
| 6 | 2.2 | Footings | 5d | 2013-06-12 | 2013-06-18 | 5 | 0d |  |
| 7 | 2.3 | Concrete | 6d | 2013-06-19 | 2013-06-26 | 6 | 0d |  |
| 8 | 2.4 | Base brickwork | 6d | 2013-06-27 | 2013-07-04 | 7 | 0d |  |
| 9 | 2.5 | Plumbing and services | 4d | 2013-07-05 | 2013-07-10 | 8 | 81d | 56d |
| 10 | 3 | **Frame** | 47d | 2013-07-08 | 2013-09-10 |  | 0d |  |
| 11 | 3.1 | Floor | 10d | 2013-07-08 | 2013-07-19 | 8FS+1d | 74d | 49d |
| 12 | 3.2 | Frame | 26d | 2013-07-08 | 2013-08-12 | 8FS+1d | 0d |  |
| 13 | 3.3 | Structural steel | 10d | 2013-08-14 | 2013-08-27 | 8, 12FS+1d | 0d |  |
| 14 | 3.4 | Trussing | 10d | 2013-08-28 | 2013-09-10 | 12, 13 | 12d |  |
| 15 | 4 | **Lockup** | 51d | 2013-08-28 | 2013-11-06 |  | 0d |  |
| 16 | 4.1 | Window and door frames | 10d | 2013-08-28 | 2013-09-10 | 12, 13 | 0d |  |
| 17 | 4.2 | Brickwork | 9d | 2013-09-16 | 2013-09-26 | 16FS+3d | 0d |  |
| 18 | 4.3 | Roof structure and tile | 14d | 2013-09-27 | 2013-10-16 | 17, 14 | 0d |  |
| 19 | 4.4 | Fix rainwater goods | 3d | 2013-10-17 | 2013-10-21 | 18 | 0d |  |
| 20 | 4.5 | Exterior decoration | 10d | 2013-10-22 | 2013-11-04 | 19 | 0d |  |
| 21 | 4.6 | Waterproofing | 2d | 2013-11-05 | 2013-11-06 | 20 | 45d |  |
| 22 | 5 | **First Fix** | 8d | 2013-09-27 | 2013-10-08 | 17 | 25d |  |
| 23 | 5.1 | First fix carpentry | 8d | 2013-09-27 | 2013-10-08 | 11 | 25d |  |
| 24 | 5.2 | First fix plumbing | 6d | 2013-09-27 | 2013-10-04 | 9 | 27d |  |
| 25 | 5.3 | First fix electrics | 8d | 2013-09-27 | 2013-10-08 | 9 | 25d |  |

| ID | WBS | Task | Type | Duration | Start | Finish | Predecessors | Total slack |
| --- | --- | --- | --- | --- | --- | --- | --- | --- |
| 26 | 6 | **Fix** |  | 26d | 2013-11-05 | 2013-12-10 |  | 0d |
| 27 | 6.1 | Insulation |  | 6d | 2013-11-05 | 2013-11-12 | 20 | 0d |
| 28 | 6.2 | Plaster |  | 12d | 2013-11-13 | 2013-11-28 | 22, 27 | 0d |
| 29 | 6.3 | Floors |  | 8d | 2013-11-29 | 2013-12-10 | 28 | 0d |
| 30 | 7 | **Services** |  | 1d | 2013-12-11 | 2013-12-11 | 26 | 0d |
| 31 | 7.1 | Connect to services |  | 1d | 2013-12-11 | 2013-12-11 | 24, 25 | 0d |
| 32 | 8 | **Second Fix** |  | 9d | 2013-12-12 | 2013-12-24 | 30, 22 | 0d |
| 33 | 8.1 | Second fix carpentry |  | 7d | 2013-12-12 | 2013-12-20 |  | 2d |
| 34 | 8.2 | Second fix plumbing |  | 9d | 2013-12-12 | 2013-12-24 |  | 0d |
| 35 | 8.3 | Second fix electrics |  | 6d | 2013-12-12 | 2013-12-19 |  | 3d |
| 36 | 9 | **Finishing** |  | 17d | 2013-12-25 | 2014-01-16 | 32 | 0d |
| 37 | 9.1 | Decoration |  | 10d | 2013-12-25 | 2014-01-07 |  | 0d |
| 38 | 9.2 | Ceramic tiling |  | 6d | 2014-01-09 | 2014-01-16 | 37FS+1d | 0d |
| 39 | 10 | **Outside** |  | 6d | 2013-11-07 | 2013-11-14 | 15 | 45d |
| 40 | 10.1 | Landscaping |  | 6d | 2013-11-07 | 2013-11-14 |  | 45d |
| 41 | 10.2 | Driveway |  | 4d | 2013-11-07 | 2013-11-12 |  | 47d |
| 42 | 10.3 | Paths |  | 3d | 2013-11-07 | 2013-11-11 |  | 48d |
| 43 | 11 | **Completion** |  | 4d | 2014-01-17 | 2014-01-22 | 36, 39 | 0d |
| 44 | 11.1 | Final inspection |  | 2d | 2014-01-17 | 2014-01-20 | 21 | 0d |
| 45 | 11.2 | Correct snags |  | 2d | 2014-01-21 | 2014-01-22 | 44 | 0d |
| 46 | 12 | Signoff | milestone | 0d | 2014-01-22 | 2014-01-22 | 43 | 0d |
