# ssi-project2013advanced-example-05

Schedule from MS Project, 2013-05-01 to 2013-12-24, status date 2013-06-07, costs in $, A marks actual dates.
Schedule to build House A
SimonSezIT

## Calendars

- Standard: Mon-Fri 08:00-12:00, 13:00-17:00; Sat-Sun off.

## Resources

| Resource | Group | Unit | Rate |
| --- | --- | --- | --- |
| Laborer 1 | Laborer |  | 30 |
| Laborer 2 | Laborer |  | 30 |
| Ruth Tyler | Tiler |  | 40 |
| Master Builder |  |  | 50 |
| Electrician 1 | Electrician |  | 40 |
| Plumber 1 | Plumber |  | 40 |
| Carpenter 1 | Carpenter |  | 40 |
| Gus Pipe | Plumber |  | 40 |
| Lou Menns | Electrician |  | 40 |
| Hazel Wood | Carpenter |  | 40 |
| Inspector |  |  | 50 |
| Concrete |  |  |  |
| Bricks |  |  |  |
| Timber |  |  |  |
| Fuel |  | Litre | 1 |
| Pump |  | DayUse | 10 |
| Digger |  |  |  |
| Contract Cleaner |  |  | 50 |

## Schedule

| ID | WBS | Task | Duration | Start | Finish | Predecessors | Complete | Remaining | Baseline start | Baseline finish | Baseline duration | Total slack | Free slack | Resources | Work | Actual work | Cost | Baseline cost | Actual cost |
| --- | --- | --- | --- | --- | --- | --- | --- | --- | --- | --- | --- | --- | --- | --- | --- | --- | --- | --- | --- |
| 1 | 1 | **Site** | 6d | 2013-05-01 A | 2013-05-08 A |  | 100% |  | 2013-06-13 | 2013-06-20 | 6d |  |  |  | 0.48h | 0.48h | 14.4 | 14.4 | 14.4 |
| 2 | 1.1 | Clear site | 4d | 2013-05-01 A | 2013-05-06 A |  | 100% |  | 2013-06-13 | 2013-06-18 | 4d |  |  | Laborer 1 | 0.32h | 0.32h | 9.6 | 9.6 | 9.6 |
| 3 | 1.2 | Set out | 2d | 2013-05-07 A | 2013-05-08 A | 2 | 100% |  | 2013-06-19 | 2013-06-20 | 2d |  |  | Laborer 1 | 0.16h | 0.16h | 4.8 | 4.8 | 4.8 |
| 4 | 2 | **Base** | 24d | 2013-05-09 A | 2013-06-11 | 1 | 88% | 3d | 2013-06-21 | 2013-07-24 | 24d | 81d |  |  | 192h | 168h | 5,760 | 5,760 | 5,040 |
| 5 | 2.1 | Trenches | 3d | 2013-05-09 A | 2013-05-13 A |  | 100% |  | 2013-06-21 | 2013-06-25 | 3d |  |  | Laborer 2 | 24h | 24h | 720 | 720 | 720 |
| 6 | 2.2 | Footings | 5d | 2013-05-14 A | 2013-05-20 A | 5 | 100% |  | 2013-06-26 | 2013-07-02 | 5d |  |  | Laborer 2 | 40h | 40h | 1,200 | 1,200 | 1,200 |
| 7 | 2.3 | Concrete | 6d | 2013-05-21 A | 2013-05-28 A | 6 | 100% |  | 2013-07-03 | 2013-07-10 | 6d |  |  | Laborer 1 | 48h | 48h | 1,440 | 1,440 | 1,440 |
| 8 | 2.4 | Base brickwork | 6d | 2013-05-29 A | 2013-06-05 A | 7 | 100% |  | 2013-07-11 | 2013-07-18 | 6d |  |  | Laborer 1 | 48h | 48h | 1,440 | 1,440 | 1,440 |
| 9 | 2.5 | Plumbing and services | 4d | 2013-06-06 A | 2013-06-11 | 8 | 25% | 3d | 2013-07-19 | 2013-07-24 | 4d | 81d | 56d | Laborer 2 | 32h | 8h | 960 | 960 | 240 |
| 10 | 3 | **Frame** | 47d | 2013-06-07 A | 2013-08-12 |  | 16% | 39.45d | 2013-07-22 | 2013-09-24 | 47d | 37d |  |  | 448h | 72h | 13,440 | 13,440 | 2,160 |
| 11 | 3.1 | Floor | 10d | 2013-06-07 A | 2013-06-20 | 8FS+1d | 25% | 7.5d | 2013-07-22 | 2013-08-02 | 10d | 74d | 49d | Laborer 1 | 80h | 20h | 2,400 | 2,400 | 600 |
| 12 | 3.2 | Frame | 26d | 2013-06-07 A | 2013-07-12 | 8FS+1d | 25% | 19.5d | 2013-07-22 | 2013-08-26 | 26d | 0d |  | Laborer 2 | 208h | 52h | 6,240 | 6,240 | 1,560 |
| 13 | 3.3 | Structural steel | 10d | 2013-07-16 | 2013-07-29 | 8, 12FS+1d |  |  | 2013-08-28 | 2013-09-10 | 10d | 0d |  | Laborer 1 | 80h |  | 2,400 | 2,400 |  |
| 14 | 3.4 | Trussing | 10d | 2013-07-30 | 2013-08-12 | 12, 13 |  |  | 2013-09-11 | 2013-09-24 | 10d | 12d |  | Laborer 2 | 80h |  | 2,400 | 2,400 |  |
| 15 | 4 | **Lockup** | 51d | 2013-07-30 | 2013-10-08 |  |  |  | 2013-09-11 | 2013-11-20 | 51d | 0d |  |  | 384h |  | 12,832 | 12,640 |  |
| 16 | 4.1 | Window and door frames | 10d | 2013-07-30 | 2013-08-12 | 12, 13 |  |  | 2013-09-11 | 2013-09-24 | 10d | 0d |  | Laborer 1 | 80h |  | 2,400 | 2,400 |  |
| 17 | 4.2 | Brickwork | 9d | 2013-08-16 | 2013-08-28 | 16FS+3d |  |  | 2013-09-30 | 2013-10-10 | 9d | 0d |  | Laborer 1 | 72h |  | 2,160 | 2,160 |  |
| 18 | 4.3 | Roof structure and tile | 14d | 2013-08-29 | 2013-09-17 | 17, 14 |  |  | 2013-10-11 | 2013-10-30 | 14d | 0d |  | Ruth Tyler | 112h |  | 4,672 | 4,480 |  |
| 19 | 4.4 | Fix rainwater goods | 3d | 2013-09-18 | 2013-09-20 | 18 |  |  | 2013-10-31 | 2013-11-04 | 3d | 0d |  | Laborer 1 | 24h |  | 720 | 720 |  |
| 20 | 4.5 | Exterior decoration | 10d | 2013-09-23 | 2013-10-04 | 19 |  |  | 2013-11-05 | 2013-11-18 | 10d | 0d |  | Laborer 2 | 80h |  | 2,400 | 2,400 |  |
| 21 | 4.6 | Waterproofing | 2d | 2013-10-07 | 2013-10-08 | 20 |  |  | 2013-11-19 | 2013-11-20 | 2d | 45d |  | Laborer 1 | 16h |  | 480 | 480 |  |
| 22 | 5 | **First Fix** | 8d | 2013-08-29 | 2013-09-09 | 17 |  |  | 2013-10-11 | 2013-10-22 | 8d | 25d |  |  | 176h |  | 7,104 | 7,040 |  |
| 23 | 5.1 | First fix carpentry | 8d | 2013-08-29 | 2013-09-09 | 11 |  |  | 2013-10-11 | 2013-10-22 | 8d | 25d |  | Carpenter 1 | 64h |  | 2,560 | 2,560 |  |
| 24 | 5.2 | First fix plumbing | 6d | 2013-08-29 | 2013-09-05 | 9 |  |  | 2013-10-11 | 2013-10-18 | 6d | 27d |  | Gus Pipe | 48h |  | 1,984 | 1,920 |  |
| 25 | 5.3 | First fix electrics | 8d | 2013-08-29 | 2013-09-09 | 9 |  |  | 2013-10-11 | 2013-10-22 | 8d | 25d |  | Electrician 1 | 64h |  | 2,560 | 2,560 |  |

| ID | WBS | Task | Type | Duration | Start | Finish | Predecessors | Baseline start | Baseline finish | Baseline duration | Total slack | Resources | Work | Cost | Baseline cost |
| --- | --- | --- | --- | --- | --- | --- | --- | --- | --- | --- | --- | --- | --- | --- | --- |
| 26 | 6 | **Fix** |  | 26d | 2013-10-07 | 2013-11-11 |  | 2013-11-19 | 2013-12-24 | 26d | 0d |  | 208h | 6,240 | 6,240 |
| 27 | 6.1 | Insulation |  | 6d | 2013-10-07 | 2013-10-14 | 20 | 2013-11-19 | 2013-11-26 | 6d | 0d | Laborer 2 | 48h | 1,440 | 1,440 |
| 28 | 6.2 | Plaster |  | 12d | 2013-10-15 | 2013-10-30 | 22, 27 | 2013-11-27 | 2013-12-12 | 12d | 0d | Laborer 1 | 96h | 2,880 | 2,880 |
| 29 | 6.3 | Floors |  | 8d | 2013-10-31 | 2013-11-11 | 28 | 2013-12-13 | 2013-12-24 | 8d | 0d | Laborer 2 | 64h | 1,920 | 1,920 |
| 30 | 7 | **Services** |  | 1d | 2013-11-12 | 2013-11-12 | 26 | 2013-12-25 | 2013-12-25 | 1d | 0d |  | 8h | 240 | 240 |
| 31 | 7.1 | Connect to services |  | 1d | 2013-11-12 | 2013-11-12 | 24, 25 | 2013-12-25 | 2013-12-25 | 1d | 0d | Laborer 1 | 8h | 240 | 240 |
| 32 | 8 | **Second Fix** |  | 9d | 2013-11-13 | 2013-11-25 | 30, 22 | 2013-12-26 | 2014-01-07 | 9d | 0d |  | 176h | 7,248 | 7,040 |
| 33 | 8.1 | Second fix carpentry |  | 7d | 2013-11-13 | 2013-11-21 |  | 2013-12-26 | 2014-01-03 | 7d | 2d | Hazel Wood | 56h | 2,352 | 2,240 |
| 34 | 8.2 | Second fix plumbing |  | 9d | 2013-11-13 | 2013-11-25 |  | 2013-12-26 | 2014-01-07 | 9d | 0d | Plumber 1 | 72h | 2,880 | 2,880 |
| 35 | 8.3 | Second fix electrics |  | 6d | 2013-11-13 | 2013-11-20 |  | 2013-12-26 | 2014-01-02 | 6d | 3d | Lou Menns | 48h | 2,016 | 1,920 |
| 36 | 9 | **Finishing** |  | 17d | 2013-11-26 | 2013-12-18 | 32 | 2014-01-08 | 2014-01-30 | 17d | 0d |  | 128h | 3,840 | 3,840 |
| 37 | 9.1 | Decoration |  | 10d | 2013-11-26 | 2013-12-09 |  | 2014-01-08 | 2014-01-21 | 10d | 0d | Laborer 2 | 80h | 2,400 | 2,400 |
| 38 | 9.2 | Ceramic tiling |  | 6d | 2013-12-11 | 2013-12-18 | 37FS+1d | 2014-01-23 | 2014-01-30 | 6d | 0d | Laborer 1 | 48h | 1,440 | 1,440 |
| 39 | 10 | **Outside** |  | 6d | 2013-10-09 | 2013-10-16 | 15 | 2013-11-21 | 2013-11-28 | 6d | 45d |  | 104h | 3,120 | 3,120 |
| 40 | 10.1 | Landscaping |  | 6d | 2013-10-09 | 2013-10-16 |  | 2013-11-21 | 2013-11-28 | 6d | 45d | Laborer 1 | 48h | 1,440 | 1,440 |
| 41 | 10.2 | Driveway |  | 4d | 2013-10-09 | 2013-10-14 |  | 2013-11-21 | 2013-11-26 | 4d | 47d | Laborer 2 | 32h | 960 | 960 |
| 42 | 10.3 | Paths |  | 3d | 2013-10-09 | 2013-10-11 |  | 2013-11-21 | 2013-11-25 | 3d | 48d | Laborer 2 | 24h | 720 | 720 |
| 43 | 11 | **Completion** |  | 4d | 2013-12-19 | 2013-12-24 | 36, 39 | 2014-01-31 | 2014-02-05 | 4d | 0d |  | 32h | 1,280 | 1,280 |
| 44 | 11.1 | Final inspection |  | 2d | 2013-12-19 | 2013-12-20 | 21 | 2014-01-31 | 2014-02-03 | 2d | 0d | Inspector | 16h | 800 | 800 |
| 45 | 11.2 | Correct snags |  | 2d | 2013-12-23 | 2013-12-24 | 44 | 2014-02-04 | 2014-02-05 | 2d | 0d | Laborer 1 | 16h | 480 | 480 |
| 46 | 12 | Signoff | milestone | 0d | 2013-12-24 | 2013-12-24 | 43 | 2014-02-05 | 2014-02-05 |  | 0d | Inspector |  |  |  |
