# ssi-project2013advanced-example-08

Schedule from MS Project, 2013-05-01 to 2014-01-14, status date 2013-06-28, costs in $, A marks actual dates.
Schedule to build House A
SimonSezIT

## Calendars

- Standard: Mon-Fri 08:00-12:00, 13:00-17:00; Sat-Sun off.

## Resources

| Resource | Group | Unit | Rate |
| --- | --- | --- | --- |
| Laborer 1 | Laborer |  | 30 |
| Laborer 2 | Laborer |  | 30 |
| Ruth Tyler | Tiler |  | 40 |
| Master Builder |  |  | 50 |
| Electrician 1 | Electrician |  | 40 |
| Plumber 1 | Plumber |  | 40 |
| Carpenter 1 | Carpenter |  | 40 |
| Gus Pipe | Plumber |  | 40 |
| Lou Menns | Electrician |  | 40 |
| Hazel Wood | Carpenter |  | 40 |
| Inspector |  |  | 50 |
| Concrete |  |  |  |
| Bricks |  |  |  |
| Timber |  |  |  |
| Fuel |  | Litre | 1 |
| Pump |  | DayUse | 10 |
| Digger |  |  |  |
| Contract Cleaner |  |  | 50 |

## Schedule

| ID | WBS | Task | Duration | Start | Finish | Predecessors | Complete | Remaining | Baseline start | Baseline finish | Baseline duration | Total slack | Free slack | Resources | Work | Actual work | Cost | Baseline cost | Actual cost |
| --- | --- | --- | --- | --- | --- | --- | --- | --- | --- | --- | --- | --- | --- | --- | --- | --- | --- | --- | --- |
| 1 | 1 | **Site** | 6d | 2013-05-01 A | 2013-05-08 A |  | 100% |  | 2013-05-01 | 2013-05-08 | 6d |  |  |  | 0.48h | 0.48h | 14.4 | 14.4 | 14.4 |
| 2 | 1.1 | Clear site | 4d | 2013-05-01 A | 2013-05-06 A |  | 100% |  | 2013-05-01 | 2013-05-06 | 4d |  |  | Laborer 1 | 0.32h | 0.32h | 9.6 | 9.6 | 9.6 |
| 3 | 1.2 | Set out | 2d | 2013-05-07 A | 2013-05-08 A | 2 | 100% |  | 2013-05-07 | 2013-05-08 | 2d |  |  | Laborer 1 | 0.16h | 0.16h | 4.8 | 4.8 | 4.8 |
| 4 | 2 | **Base** | 24d | 2013-05-09 A | 2013-06-11 | 1 | 96% | 1d | 2013-05-09 | 2013-06-11 | 24d | 95.38d |  |  | 192h | 184h | 5,760 | 5,760 | 5,520 |
| 5 | 2.1 | Trenches | 3d | 2013-05-09 A | 2013-05-13 A |  | 100% |  | 2013-05-09 | 2013-05-13 | 3d |  |  | Laborer 2 | 24h | 24h | 720 | 720 | 720 |
| 6 | 2.2 | Footings | 5d | 2013-05-14 A | 2013-05-20 A | 5 | 100% |  | 2013-05-14 | 2013-05-20 | 5d |  |  | Laborer 2 | 40h | 40h | 1,200 | 1,200 | 1,200 |
| 7 | 2.3 | Concrete | 6d | 2013-05-21 A | 2013-05-28 A | 6 | 100% |  | 2013-05-21 | 2013-05-28 | 6d |  |  | Laborer 1 | 48h | 48h | 1,440 | 1,440 | 1,440 |
| 8 | 2.4 | Base brickwork | 6d | 2013-05-29 A | 2013-06-05 A | 7 | 100% |  | 2013-05-29 | 2013-06-05 | 6d |  |  | Laborer 1 | 48h | 48h | 1,440 | 1,440 | 1,440 |
| 9 | 2.5 | Plumbing and services | 4d | 2013-06-06 A | 2013-06-11 | 8 | 75% | 1d | 2013-06-06 | 2013-06-11 | 4d | 95.38d | 64.62d | Laborer 2 | 32h | 24h | 960 | 960 | 720 |
| 10 | 3 | **Frame** | 53.5d | 2013-06-07 A | 2013-08-21 |  | 35% | 34.88d | 2013-06-07 | 2013-08-12 | 47d | 43.88d |  |  | 510h | 177.5h | 15,300 | 13,440 | 5,325 |
| 11 | 3.1 | Floor | 11.25d | 2013-06-07 A | 2013-06-24 | 8FS+1d | 75% | 2.81d | 2013-06-07 | 2013-06-20 | 10d | 86.12d | 56.38d | Laborer 1 | 90h | 67.5h | 2,700 | 2,400 | 2,025 |
| 12 | 3.2 | Frame | 27.5d | 2013-06-07 A | 2013-07-16 | 8FS+1d | 50% | 13.75d | 2013-06-07 | 2013-07-12 | 26d | 0d |  | Laborer 2 | 220h | 110h | 6,600 | 6,240 | 3,300 |
| 13 | 3.3 | Structural steel | 12.5d | 2013-07-17 | 2013-08-02 | 8, 12FS+1d |  |  | 2013-07-16 | 2013-07-29 | 10d | 0d |  | Laborer 1 | 100h |  | 3,000 | 2,400 |  |
| 14 | 3.4 | Trussing | 12.5d | 2013-08-05 | 2013-08-21 | 12, 13 |  |  | 2013-07-30 | 2013-08-12 | 10d | 14.12d |  | Laborer 2 | 100h |  | 3,000 | 2,400 |  |
| 15 | 4 | **Lockup** | 61.88d | 2013-08-05 | 2013-10-29 |  |  |  | 2013-07-30 | 2013-10-08 | 51d | 0d |  |  | 471h |  | 15,714 | 12,832 |  |
| 16 | 4.1 | Window and door frames | 12.38d | 2013-08-05 | 2013-08-21 | 12, 13 |  |  | 2013-07-30 | 2013-08-12 | 10d | 0d |  | Laborer 1 | 99h |  | 2,970 | 2,400 |  |
| 17 | 4.2 | Brickwork | 11.25d | 2013-08-26 | 2013-09-10 | 16FS+3d |  |  | 2013-08-16 | 2013-08-28 | 9d | 0d |  | Laborer 1 | 90h |  | 2,700 | 2,160 |  |
| 18 | 4.3 | Roof structure and tile | 16.5d | 2013-09-10 | 2013-10-03 | 17, 14 |  |  | 2013-08-29 | 2013-09-17 | 14d | 0d |  | Ruth Tyler | 132h |  | 5,544 | 4,672 |  |
| 19 | 4.4 | Fix rainwater goods | 3.75d | 2013-10-03 | 2013-10-08 | 18 |  |  | 2013-09-18 | 2013-09-20 | 3d | 0d |  | Laborer 1 | 30h |  | 900 | 720 |  |
| 20 | 4.5 | Exterior decoration | 12.5d | 2013-10-08 | 2013-10-25 | 19 |  |  | 2013-09-23 | 2013-10-04 | 10d | 0d |  | Laborer 2 | 100h |  | 3,000 | 2,400 |  |
| 21 | 4.6 | Waterproofing | 2.5d | 2013-10-25 | 2013-10-29 | 20 |  |  | 2013-10-07 | 2013-10-08 | 2d | 44.5d |  | Laborer 1 | 20h |  | 600 | 480 |  |
| 22 | 5 | **First Fix** | 9d | 2013-09-10 | 2013-09-23 | 17 |  |  | 2013-08-29 | 2013-09-09 | 8d | 29.75d |  |  | 192h |  | 7,792 | 7,104 |  |
| 23 | 5.1 | First fix carpentry | 9d | 2013-09-10 | 2013-09-23 | 11 |  |  | 2013-08-29 | 2013-09-09 | 8d | 29.75d |  | Carpenter 1 | 72h |  | 2,880 | 2,560 |  |
| 24 | 5.2 | First fix plumbing | 7d | 2013-09-10 | 2013-09-19 | 9 |  |  | 2013-08-29 | 2013-09-05 | 6d | 31.75d |  | Gus Pipe | 56h |  | 2,352 | 1,984 |  |
| 25 | 5.3 | First fix electrics | 8d | 2013-09-10 | 2013-09-20 | 9 |  |  | 2013-08-29 | 2013-09-09 | 8d | 30.75d |  | Electrician 1 | 64h |  | 2,560 | 2,560 |  |

| ID | WBS | Task | Type | Duration | Start | Finish | Predecessors | Baseline start | Baseline finish | Baseline duration | Total slack | Resources | Work | Cost | Baseline cost |
| --- | --- | --- | --- | --- | --- | --- | --- | --- | --- | --- | --- | --- | --- | --- | --- |
| 26 | 6 | **Fix** |  | 26d | 2013-10-25 | 2013-12-02 |  | 2013-10-07 | 2013-11-11 | 26d | 0d |  | 208h | 6,240 | 6,240 |
| 27 | 6.1 | Insulation |  | 6d | 2013-10-25 | 2013-11-04 | 20 | 2013-10-07 | 2013-10-14 | 6d | 0d | Laborer 2 | 48h | 1,440 | 1,440 |
| 28 | 6.2 | Plaster |  | 12d | 2013-11-04 | 2013-11-20 | 22, 27 | 2013-10-15 | 2013-10-30 | 12d | 0d | Laborer 1 | 96h | 2,880 | 2,880 |
| 29 | 6.3 | Floors |  | 8d | 2013-11-20 | 2013-12-02 | 28 | 2013-10-31 | 2013-11-11 | 8d | 0d | Laborer 2 | 64h | 1,920 | 1,920 |
| 30 | 7 | **Services** |  | 1d | 2013-12-02 | 2013-12-03 | 26 | 2013-11-12 | 2013-11-12 | 1d | 0d |  | 8h | 240 | 240 |
| 31 | 7.1 | Connect to services |  | 1d | 2013-12-02 | 2013-12-03 | 24, 25 | 2013-11-12 | 2013-11-12 | 1d | 0d | Laborer 1 | 8h | 240 | 240 |
| 32 | 8 | **Second Fix** |  | 9d | 2013-12-03 | 2013-12-16 | 30, 22 | 2013-11-13 | 2013-11-25 | 9d | 0d |  | 176h | 7,248 | 7,248 |
| 33 | 8.1 | Second fix carpentry |  | 7d | 2013-12-03 | 2013-12-12 |  | 2013-11-13 | 2013-11-21 | 7d | 2d | Hazel Wood | 56h | 2,352 | 2,352 |
| 34 | 8.2 | Second fix plumbing |  | 9d | 2013-12-03 | 2013-12-16 |  | 2013-11-13 | 2013-11-25 | 9d | 0d | Plumber 1 | 72h | 2,880 | 2,880 |
| 35 | 8.3 | Second fix electrics |  | 6d | 2013-12-03 | 2013-12-11 |  | 2013-11-13 | 2013-11-20 | 6d | 3d | Lou Menns | 48h | 2,016 | 2,016 |
| 36 | 9 | **Finishing** |  | 17d | 2013-12-16 | 2014-01-08 | 32 | 2013-11-26 | 2013-12-18 | 17d | 0d |  | 128h | 3,840 | 3,840 |
| 37 | 9.1 | Decoration |  | 10d | 2013-12-16 | 2013-12-30 |  | 2013-11-26 | 2013-12-09 | 10d | 0d | Laborer 2 | 80h | 2,400 | 2,400 |
| 38 | 9.2 | Ceramic tiling |  | 6d | 2013-12-31 | 2014-01-08 | 37FS+1d | 2013-12-11 | 2013-12-18 | 6d | 0d | Laborer 1 | 48h | 1,440 | 1,440 |
| 39 | 10 | **Outside** |  | 6d | 2013-10-29 | 2013-11-06 | 15 | 2013-10-09 | 2013-10-16 | 6d | 44.5d |  | 104h | 3,120 | 3,120 |
| 40 | 10.1 | Landscaping |  | 6d | 2013-10-29 | 2013-11-06 |  | 2013-10-09 | 2013-10-16 | 6d | 44.5d | Laborer 1 | 48h | 1,440 | 1,440 |
| 41 | 10.2 | Driveway |  | 4d | 2013-10-29 | 2013-11-04 |  | 2013-10-09 | 2013-10-14 | 4d | 46.5d | Laborer 2 | 32h | 960 | 960 |
| 42 | 10.3 | Paths |  | 3d | 2013-10-29 | 2013-11-01 |  | 2013-10-09 | 2013-10-11 | 3d | 47.5d | Laborer 2 | 24h | 720 | 720 |
| 43 | 11 | **Completion** |  | 4d | 2014-01-08 | 2014-01-14 | 36, 39 | 2013-12-19 | 2013-12-24 | 4d | 0d |  | 32h | 1,280 | 1,280 |
| 44 | 11.1 | Final inspection |  | 2d | 2014-01-08 | 2014-01-10 | 21 | 2013-12-19 | 2013-12-20 | 2d | 0d | Inspector | 16h | 800 | 800 |
| 45 | 11.2 | Correct snags |  | 2d | 2014-01-10 | 2014-01-14 | 44 | 2013-12-23 | 2013-12-24 | 2d | 0d | Laborer 1 | 16h | 480 | 480 |
| 46 | 12 | Signoff | milestone | 0d | 2014-01-14 | 2014-01-14 | 43 | 2013-12-24 | 2013-12-24 |  | 0d | Inspector |  |  |  |
