# ssi-project2013advanced-example-12

Schedule from MS Project, 2013-05-01 to 2014-01-31, status date 2013-07-26, costs in $, A marks actual dates.
Schedule to build House A
SimonSezIT

## Calendars

- Standard: Mon-Fri 08:00-12:00, 13:00-17:00; Sat-Sun off.

## Resources

| Resource | Group | Unit | Rate |
| --- | --- | --- | --- |
| Laborer 1 | Laborer |  | 30 |
| Laborer 2 | Laborer |  | 30 |
| Ruth Tyler | Tiler |  | 40 |
| Master Builder |  |  | 50 |
| Electrician 1 | Electrician |  | 40 |
| Plumber 1 | Plumber |  | 40 |
| Carpenter 1 | Carpenter |  | 40 |
| Gus Pipe | Plumber |  | 40 |
| Lou Menns | Electrician |  | 40 |
| Hazel Wood | Carpenter |  | 40 |
| Inspector |  |  | 50 |
| Concrete |  | Yard | 78 |
| Bricks |  | Thousand | 380 |
| Timber |  | Length | 6.4 |
| Fuel |  | Litre | 1 |
| Pump |  | DayUse | 10 |
| Digger |  |  |  |
| Contract Cleaner |  |  | 50 |

## Schedule

| ID | WBS | Task | Duration | Start | Finish | Predecessors | Complete | Remaining | Baseline start | Baseline finish | Baseline duration | Total slack | Free slack | Resources | Work | Actual work | Cost | Baseline cost | Actual cost |
| --- | --- | --- | --- | --- | --- | --- | --- | --- | --- | --- | --- | --- | --- | --- | --- | --- | --- | --- | --- |
| 1 | 1 | **Site** | 6d | 2013-05-01 A | 2013-05-08 A |  | 100% |  | 2013-05-01 | 2013-05-08 | 6d |  |  |  | 0.48h | 0.48h | 14.4 | 14.4 | 14.4 |
| 2 | 1.1 | Clear site | 4d | 2013-05-01 A | 2013-05-06 A |  | 100% |  | 2013-05-01 | 2013-05-06 | 4d |  |  | Laborer 1 | 0.32h | 0.32h | 9.6 | 9.6 | 9.6 |
| 3 | 1.2 | Set out | 2d | 2013-05-07 A | 2013-05-08 A | 2 | 100% |  | 2013-05-07 | 2013-05-08 | 2d |  |  | Laborer 1 | 0.16h | 0.16h | 4.8 | 4.8 | 4.8 |
| 4 | 2 | **Base** | 28.62d | 2013-05-09 A | 2013-06-18 | 1 | 83% | 4.95d | 2013-05-09 | 2013-06-11 | 24d | 103.88d |  |  | 192h | 172h | 6,080 | 6,080 | 5,400 |
| 5 | 2.1 | Trenches | 3d | 2013-05-09 A | 2013-05-13 A |  | 100% |  | 2013-05-09 | 2013-05-13 | 3d |  |  | Laborer 2 | 24h | 24h | 720 | 720 | 720 |
| 6 | 2.2 | Footings | 5d | 2013-05-14 A | 2013-05-20 A | 5 | 100% |  | 2013-05-14 | 2013-05-20 | 5d |  |  | Laborer 2 | 40h | 40h | 1,200 | 1,200 | 1,200 |
| 7 | 2.3 | Concrete | 6d | 2013-05-21 A | 2013-05-28 A | 6 | 100% |  | 2013-05-21 | 2013-05-28 | 6d |  |  | Laborer 1 | 48h | 48h | 1,440 | 1,440 | 1,440 |
| 8 | 2.4 | Base brickwork | 8d | 2013-05-29 A | 2013-06-17 | 7 | 56% | 3.5d | 2013-05-29 | 2013-06-05 | 6d | 0d |  | Laborer 1 | 48h | 36h | 1,440 | 1,440 | 1,080 |
| 9 | 2.5 | Plumbing and services | 4d | 2013-06-06 A | 2013-06-18 | 8 | 75% | 1d | 2013-06-06 | 2013-06-11 | 4d | 103.88d | 70.88d | Plumber 1 | 32h | 24h | 1,280 | 1,280 | 960 |
| 10 | 3 | **Frame** | 58.5d | 2013-06-07 A | 2013-08-28 |  | 62% | 22.34d | 2013-06-07 | 2013-08-21 | 53.5d | 20d |  |  | 510h | 335h | 18,500 | 18,500 | 12,250 |
| 11 | 3.1 | Floor | 11.25d | 2013-06-07 A | 2013-06-26 A | 8FS+1d | 100% |  | 2013-06-07 | 2013-06-24 | 11.25d |  |  | Laborer 1 | 90h | 90h | 2,700 | 2,700 | 2,700 |
| 12 | 3.2 | Frame | 27.5d | 2013-06-07 A | 2013-07-16 A | 8FS+1d | 100% |  | 2013-06-07 | 2013-07-16 | 27.5d |  |  | Carpenter 1 | 220h | 220h | 8,800 | 8,800 | 8,800 |
| 13 | 3.3 | Structural steel | 15d | 2013-07-17 A | 2013-08-07 | 8, 12FS+1d | 25% | 11.25d | 2013-07-17 | 2013-08-02 | 12.5d | 0d |  | Laborer 1 | 100h | 25h | 3,000 | 3,000 | 750 |
| 14 | 3.4 | Trussing | 15d | 2013-08-07 | 2013-08-28 | 12, 13 |  |  | 2013-08-05 | 2013-08-21 | 12.5d | 20d |  | Ruth Tyler | 100h |  | 4,000 | 4,000 |  |
| 15 | 4 | **Lockup** | 70.5d | 2013-08-07 | 2013-11-13 |  |  |  | 2013-08-05 | 2013-10-29 | 61.88d | 0d |  |  | 465h |  | 16,524 | 16,704 |  |
| 16 | 4.1 | Window and door frames | 18d | 2013-08-07 | 2013-09-02 | 12, 13 |  |  | 2013-08-05 | 2013-08-21 | 12.38d | 0d |  | Carpenter 1 [50%] | 99h |  | 3,960 | 3,960 |  |
| 17 | 4.2 | Brickwork | 14d | 2013-09-05 | 2013-09-25 | 16FS+3d |  |  | 2013-08-26 | 2013-09-10 | 11.25d | 0d |  | Laborer 1 | 90h |  | 2,700 | 2,700 |  |
| 18 | 4.3 | Roof structure and tile | 17d | 2013-09-25 | 2013-10-18 | 17, 14 |  |  | 2013-09-10 | 2013-10-03 | 16.5d | 0d |  | Ruth Tyler | 132h |  | 5,544 | 5,544 |  |
| 19 | 4.4 | Fix rainwater goods | 4d | 2013-10-18 | 2013-10-24 | 18 |  |  | 2013-10-03 | 2013-10-08 | 3.75d | 0d |  | Laborer 1 | 30h |  | 900 | 900 |  |
| 20 | 4.5 | Exterior decoration | 12d | 2013-10-24 | 2013-11-11 | 19 |  |  | 2013-10-08 | 2013-10-25 | 12.5d | 0d |  | Laborer 2 | 94h |  | 2,820 | 3,000 |  |
| 21 | 4.6 | Waterproofing | 2.5d | 2013-11-11 | 2013-11-13 | 20 |  |  | 2013-10-25 | 2013-10-29 | 2.5d | 24.12d |  | Laborer 2 | 20h |  | 600 | 600 |  |
| 22 | 5 | **First Fix** | 10d | 2013-09-25 | 2013-10-09 | 17 |  |  | 2013-09-10 | 2013-09-23 | 9d | 31d |  |  | 192h |  | 7,792 | 7,792 |  |
| 23 | 5.1 | First fix carpentry | 10d | 2013-09-25 | 2013-10-09 | 11 |  |  | 2013-09-10 | 2013-09-23 | 9d | 31d |  | Carpenter 1 | 72h |  | 2,880 | 2,880 |  |
| 24 | 5.2 | First fix plumbing | 8d | 2013-09-25 | 2013-10-07 | 9 |  |  | 2013-09-10 | 2013-09-19 | 7d | 33d |  | Gus Pipe | 56h |  | 2,352 | 2,352 |  |
| 25 | 5.3 | First fix electrics | 8d | 2013-09-25 | 2013-10-07 | 9 |  |  | 2013-09-10 | 2013-09-20 | 8d | 33d |  | Electrician 1 | 64h |  | 2,560 | 2,560 |  |

| ID | WBS | Task | Type | Duration | Start | Finish | Predecessors | Baseline start | Baseline finish | Baseline duration | Total slack | Free slack | Resources | Work | Cost | Baseline cost |
| --- | --- | --- | --- | --- | --- | --- | --- | --- | --- | --- | --- | --- | --- | --- | --- | --- |
| 26 | 6 | **Fix** |  | 28d | 2013-11-11 | 2013-12-19 |  | 2013-10-25 | 2013-12-02 | 26d | 0d |  |  | 208h | 8,160 | 8,160 |
| 27 | 6.1 | Insulation |  | 8d | 2013-11-11 | 2013-11-21 | 20 | 2013-10-25 | 2013-11-04 | 6d | 0d |  | Laborer 1 | 48h | 1,440 | 1,440 |
| 28 | 6.2 | Plaster |  | 12d | 2013-11-21 | 2013-12-09 | 22, 27 | 2013-11-04 | 2013-11-20 | 12d | 0d |  | Master Builder | 96h | 4,800 | 4,800 |
| 29 | 6.3 | Floors |  | 8d | 2013-12-09 | 2013-12-19 | 28 | 2013-11-20 | 2013-12-02 | 8d | 0d |  | Laborer 2 | 64h | 1,920 | 1,920 |
| 30 | 7 | **Services** |  | 1d | 2013-12-19 | 2013-12-20 | 26 | 2013-12-02 | 2013-12-03 | 1d | 0d |  |  | 8h | 240 | 240 |
| 31 | 7.1 | Connect to services |  | 1d | 2013-12-19 | 2013-12-20 | 24, 25 | 2013-12-02 | 2013-12-03 | 1d | 0d |  | Laborer 1 | 8h | 240 | 240 |
| 32 | 8 | **Second Fix** |  | 10d | 2013-12-20 | 2014-01-03 | 30, 22 | 2013-12-03 | 2013-12-16 | 9d | 0d |  |  | 192h | 7,920 | 7,248 |
| 33 | 8.1 | Second fix carpentry |  | 7d | 2013-12-20 | 2013-12-31 |  | 2013-12-03 | 2013-12-12 | 7d | 3d |  | Hazel Wood | 56h | 2,352 | 2,352 |
| 34 | 8.2 | Second fix plumbing |  | 9d | 2013-12-20 | 2014-01-02 |  | 2013-12-03 | 2013-12-16 | 9d | 1d |  | Plumber 1 | 72h | 2,880 | 2,880 |
| 35 | 8.3 | Second fix electrics |  | 10d | 2013-12-20 | 2014-01-03 |  | 2013-12-03 | 2013-12-11 | 6d | 0d |  | Lou Menns [66.7%] | 64h | 2,688 | 2,016 |
| 36 | 9 | **Finishing** |  | 16d | 2014-01-03 | 2014-01-27 | 32 | 2013-12-16 | 2014-01-08 | 17d | 0d |  |  | 120h | 3,600 | 3,840 |
| 37 | 9.1 | Decoration |  | 9d | 2014-01-03 | 2014-01-16 |  | 2013-12-16 | 2013-12-30 | 10d | 0d |  | Laborer 2 | 72h | 2,160 | 2,400 |
| 38 | 9.2 | Ceramic tiling |  | 6d | 2014-01-17 | 2014-01-27 | 37FS+1d | 2013-12-31 | 2014-01-08 | 6d | 0d |  | Laborer 1 | 48h | 1,440 | 1,440 |
| 39 | 10 | **Outside** |  | 28.5d | 2013-11-14 | 2013-12-24 | 15 | 2013-11-04 | 2013-12-05 | 23d | 24d |  |  | 104h | 3,120 | 3,120 |
| 40 | 10.1 | Landscaping |  | 6d | 2013-11-14 | 2013-11-29 |  | 2013-11-04 | 2013-11-12 | 6d | 24.12d | 0d | Laborer 1 | 48h | 1,440 | 1,440 |
| 41 | 10.2 | Driveway |  | 4d | 2013-11-29 | 2013-12-05 | 40 | 2013-11-12 | 2013-11-18 | 4d | 37.25d |  | Laborer 2 | 32h | 960 | 960 |
| 42 | 10.3 | Paths |  | 3d | 2013-12-19 | 2013-12-24 | 40 | 2013-12-02 | 2013-12-05 | 3d | 24d |  | Laborer 2 | 24h | 720 | 720 |
| 43 | 11 | **Completion** |  | 4d | 2014-01-27 | 2014-01-31 | 36, 39 | 2014-01-08 | 2014-01-14 | 4d | 0d |  |  | 32h | 1,280 | 1,280 |
| 44 | 11.1 | Final inspection |  | 2d | 2014-01-27 | 2014-01-29 | 21 | 2014-01-08 | 2014-01-10 | 2d | 0d |  | Inspector | 16h | 800 | 800 |
| 45 | 11.2 | Correct snags |  | 2d | 2014-01-29 | 2014-01-31 | 44 | 2014-01-10 | 2014-01-14 | 2d | 0d |  | Laborer 1 | 16h | 480 | 480 |
| 46 | 12 | Signoff | milestone | 0d | 2014-01-31 | 2014-01-31 | 43 | 2014-01-14 | 2014-01-14 |  | 0d |  | Inspector |  |  |  |
